# Plan New Light International_2005Sep29

Schedule from MS Project, 2006-06-19 to 2006-08-18, costs in Bs.
GSM

## Calendars

- Standard: Mon-Fri 08:00-12:00, 13:00-17:00; Sat-Sun off.

## Resources

| Resource | Group | Rate |
| --- | --- | --- |
| GWT_Gerente de Proyecto | GWT | 60000 |
| CLP_Gerente de Proyecto | CLP |  |
| GWT_Analista 1 | GWT | 60000 |
| CLP_Analista 2 | CLP |  |
| GWT_Diseñador Gráfico 1 | GWT | 60000 |
| GWT_Socio | GWT | 60000 |
| CLP_Gerente Informática | CLP |  |
| GWT_Operaciones 1 | GWT | 60000 |

## Schedule

| ID | WBS | Task | Duration | Start | Finish | Predecessors | Total slack | Free slack | Constraint | Resources | Work | Cost |
| --- | --- | --- | --- | --- | --- | --- | --- | --- | --- | --- | --- | --- |
| 1 | CLP_M_01.2 | **Proyecto MIO** | 44d | 2006-06-19 08:00 | 2006-08-17 17:00 |  | 0.5d |  |  |  | 694h | 25,920,000 |
| 2 | CLP_M_01.2.1 | Gerencia de Proyectos | 25d | 2006-06-19 08:00 | 2006-07-21 17:00 |  | 19.5d |  |  | GWT_Gerente de Proyecto [13%]; CLP_Gerente de Proyecto [13%] | 52h | 1,560,000 |
| 3 | CLP_M_01.2.2 | Asesoría Integral de Soporte | 25d | 2006-06-19 08:00 | 2006-07-21 17:00 |  | 19.5d |  |  | GWT_Socio [10%] | 20h | 1,200,000 |
| 4 | CLP_M_01.2.3 | Kick Off del Proyecto | 4h | 2006-06-19 08:00 | 2006-06-19 12:00 |  | 6.75d | 0d |  | GWT_Gerente de Proyecto | 4h | 240,000 |
| 5 | CLP_M_01.2.4 | Definición del Alcance | 4h | 2006-06-19 13:00 | 2006-06-19 17:00 | 4 | 6.75d | 0d |  | GWT_Gerente de Proyecto; GWT_Analista 1 [50%]; CLP_Analista 2 | 10h | 360,000 |
| 6 | CLP_M_01.2.5 | Matriz de Requerimientos | 16h | 2006-06-20 08:00 | 2006-06-21 17:00 | 5 | 6.75d | 0d |  | GWT_Gerente de Proyecto [50%]; GWT_Analista 1; CLP_Analista 2 | 40h | 1,440,000 |
| 7 | CLP_M_01.2.6 | Afinar el Plan y Recursos | 8h | 2006-06-22 08:00 | 2006-06-22 17:00 | 6 | 6.75d | 0d |  | GWT_Gerente de Proyecto; GWT_Analista 1; CLP_Analista 2 | 16h | 720,000 |
| 8 | CLP_M_01.2.7 | Diseño Integral del Look&Feel | 24h | 2006-06-23 08:00 | 2006-06-27 17:00 | 7 | 6.75d | 0d |  | GWT_Diseñador Gráfico 1 | 24h | 1,440,000 |
| 9 | CLP_M_01.2.8 | **Modelo de Datos** | 4d | 2006-06-28 08:00 | 2006-07-03 17:00 | 8 | 6.75d |  |  |  | 40h | 2,400,000 |
| 10 | CLP_M_01.2.8.1 | Asesoría Análisis de Datos | 8h | 2006-06-28 08:00 | 2006-06-28 17:00 |  | 36.5d |  |  | GWT_Socio | 8h | 480,000 |
| 11 | CLP_M_01.2.8.2 | Definición y Carga de la Estructura en Net2Client | 32h | 2006-06-28 08:00 | 2006-07-03 17:00 |  | 6.75d | 0d |  | GWT_Analista 1 | 32h | 1,920,000 |
| 12 | CLP_M_01.2.9 | Adiestramiento Analista/Programador del Cliente | 5d | 2006-07-03 08:00 | 2006-07-07 17:00 |  | 0d |  | start no earlier than 2006-07-03 08:00 | CLP_Analista 2 | 40h |  |
| 13 | CLP_M_01.2.10 | **Diseño de las Formas de Entrada de Información** | 13.25d | 2006-07-04 08:00 | 2006-07-21 10:00 | 11 | 6.75d |  |  |  | 106h | 6,360,000 |
| 14 | CLP_M_01.2.10.1 | Formas Entrada 1 | 24h | 2006-07-04 08:00 | 2006-07-06 17:00 |  | 6.75d | 0d |  | GWT_Analista 1 | 24h | 1,440,000 |
| 15 | CLP_M_01.2.10.2 | Formas Entrada 2 | 24h | 2006-07-07 08:00 | 2006-07-11 17:00 | 14 | 6.75d | 0d |  | GWT_Analista 1 | 24h | 1,440,000 |
| 16 | CLP_M_01.2.10.3 | Formas Entrada 3 | 16h | 2006-07-12 08:00 | 2006-07-13 17:00 | 15 | 6.75d | 0d |  | GWT_Analista 1 | 16h | 960,000 |
| 17 | CLP_M_01.2.10.4 | Formas Entrada 4 | 16h | 2006-07-14 08:00 | 2006-07-17 17:00 | 16 | 6.75d | 0d |  | GWT_Analista 1 | 16h | 960,000 |
| 18 | CLP_M_01.2.10.5 | Formas Entrada 5 | 16h | 2006-07-18 08:00 | 2006-07-19 17:00 | 17 | 6.75d | 0d |  | GWT_Analista 1 | 16h | 960,000 |
| 19 | CLP_M_01.2.10.6 | Formas Entrada 6 | 2h | 2006-07-20 08:00 | 2006-07-20 10:00 | 18 | 6.75d | 0d |  | GWT_Analista 1 | 2h | 120,000 |
| 20 | CLP_M_01.2.10.7 | Formas Entrada 7 | 2h | 2006-07-20 10:00 | 2006-07-20 12:00 | 19 | 6.75d | 0d |  | GWT_Analista 1 | 2h | 120,000 |
| 21 | CLP_M_01.2.10.8 | Formas Entrada 8 | 2h | 2006-07-20 13:00 | 2006-07-20 15:00 | 20 | 6.75d | 0d |  | GWT_Analista 1 | 2h | 120,000 |
| 22 | CLP_M_01.2.10.9 | Formas Entrada 9 | 2h | 2006-07-20 15:00 | 2006-07-20 17:00 | 21 | 6.75d | 0d |  | GWT_Analista 1 | 2h | 120,000 |
| 23 | CLP_M_01.2.10.10 | Formas Entrada 10 | 2h | 2006-07-21 08:00 | 2006-07-21 10:00 | 22 | 6.75d |  |  | GWT_Analista 1 | 2h | 120,000 |
| 24 | CLP_M_01.2.11 | **Diseño de los Reportes (Formas de Salida)** | 18d | 2006-07-10 08:00 | 2006-08-02 17:00 | 12 | 0d |  |  |  | 198h | 3,960,000 |
| 25 | CLP_M_01.2.11.1 | Reporte Vista Extendida 1 + Grafico | 32h | 2006-07-10 08:00 | 2006-07-13 17:00 |  | 0d |  |  | CLP_Analista 2; GWT_Analista 1 [50%] | 48h | 960,000 |
| 26 | CLP_M_01.2.11.2 | Reporte Vista Extendida 2 + Grafico | 32h | 2006-07-14 08:00 | 2006-07-19 17:00 | 25 | 0d |  |  | CLP_Analista 2; GWT_Analista 1 [50%] | 48h | 960,000 |
| 27 | CLP_M_01.2.11.3 | Reporte Vista Extendida 3 + Grafico | 32h | 2006-07-20 08:00 | 2006-07-25 17:00 | 26 | 0d |  |  | CLP_Analista 2; GWT_Analista 1 [50%] | 48h | 960,000 |
| 28 | CLP_M_01.2.11.4 | Reporte Vista Extendida 4 | 8h | 2006-07-26 08:00 | 2006-07-26 17:00 | 27 | 0d |  |  | CLP_Analista 2; GWT_Analista 1 [50%] | 12h | 240,000 |
| 29 | CLP_M_01.2.11.5 | Reporte Vista Extendida 5 | 8h | 2006-07-27 08:00 | 2006-07-27 17:00 | 28 | 0d |  |  | CLP_Analista 2 [50%]; GWT_Analista 1 [25%] | 6h | 120,000 |
| 30 | CLP_M_01.2.11.6 | Reporte Vista Extendida 6 | 8h | 2006-07-28 08:00 | 2006-07-28 17:00 | 29 | 0d |  |  | CLP_Analista 2; GWT_Analista 1 [25%] | 6h | 120,000 |
| 31 | CLP_M_01.2.11.7 | Reporte Vista Extendida 7 | 8h | 2006-07-31 08:00 | 2006-07-31 17:00 | 30 | 0d |  |  | CLP_Analista 2; GWT_Analista 1 [25%] | 6h | 120,000 |
| 32 | CLP_M_01.2.11.8 | Armar las Hojas de Excel x Columnas | 16h | 2006-08-01 08:00 | 2006-08-02 17:00 | 31 | 9d |  |  | CLP_Analista 2; GWT_Analista 1 [50%] | 24h | 480,000 |

| ID | WBS | Task | Type | Duration | Start | Finish | Predecessors | Total slack | Resources | Work | Cost |
| --- | --- | --- | --- | --- | --- | --- | --- | --- | --- | --- | --- |
| 33 | CLP_M_01.2.12 | **Diseño Paneles de Control** |  | 8d | 2006-08-01 08:00 | 2006-08-10 17:00 | 23, 31 | 0d |  | 64h | 3,840,000 |
| 34 | CLP_M_01.2.12.1 | Panel de Control 1 - Comité Guía |  | 32h | 2006-08-01 08:00 | 2006-08-04 17:00 |  | 0d | GWT_Analista 1 | 32h | 1,920,000 |
| 35 | CLP_M_01.2.12.2 | Panel de Control 2 - Gerencia |  | 16h | 2006-08-07 08:00 | 2006-08-08 17:00 | 34 | 0d | GWT_Analista 1 | 16h | 960,000 |
| 36 | CLP_M_01.2.12.3 | Panel de Control 3 - ENT |  | 16h | 2006-08-09 08:00 | 2006-08-10 17:00 | 35 | 0d | GWT_Analista 1 | 16h | 960,000 |
| 37 | CLP_M_01.2.13 | Pruebas de Aceptación |  | 16h | 2006-08-11 08:00 | 2006-08-14 17:00 | 36 | 0d | GWT_Analista 1; CLP_Analista 2 | 32h | 960,000 |
| 38 | CLP_M_01.2.14 | Adiestramiento Train the Trainer |  | 24h | 2006-08-15 08:00 | 2006-08-17 17:00 | 37 | 0.5d | CLP_Analista 2; GWT_Analista 1 | 48h | 1,440,000 |
| 39 | CLP_M_01.3 | **Ambiente de Producción** |  | 3d | 2006-08-14 17:00 | 2006-08-17 17:00 | 36, 37 | 0d |  | 24h | 1,440,000 |
| 40 | CLP_M_01.3.1 | Instalación Entonación del Software Básico (Opcional-32hrs) | milestone | 0h | 2006-08-14 17:00 | 2006-08-14 17:00 |  | 0d | GWT_Operaciones 1 |  |  |
| 41 | CLP_M_01.3.2 | Instalación Net2Client |  | 4h | 2006-08-15 08:00 | 2006-08-15 12:00 | 40 | 0d | GWT_Operaciones 1 | 4h | 240,000 |
| 42 | CLP_M_01.3.3 | Migración Estructura de Datos |  | 4h | 2006-08-15 13:00 | 2006-08-15 17:00 | 41 | 0d | GWT_Operaciones 1 | 4h | 240,000 |
| 43 | CLP_M_01.3.4 | Carga Masiva a Net2Clilent |  | 16h | 2006-08-16 08:00 | 2006-08-17 17:00 | 32, 42 | 0d | GWT_Operaciones 1 | 16h | 960,000 |
| 44 | CLP_M_01.4 | Aceptación y Cierre del Proyecto |  | 4h | 2006-08-18 08:00 | 2006-08-18 12:00 | 43 | 0d | GWT_Gerente de Proyecto; CLP_Gerente de Proyecto | 8h | 240,000 |

Notes:
- 38: Máx. 10 participantes que a su vez adiestrarán al resto de la población de 120 participantes
